# CDEG

Schedule from MS Project, 2020-08-03 to 2021-03-09, status date 2021-03-10, costs in $, A marks actual dates.

## Calendars

- CALENDARIO PROYECTO: Mon-Fri 08:00-12:00, 13:00-17:00; Sat-Sun off. Exceptions (off unless hours are given): 2020-10-12 (DIA DE LA RAZA), 2020-11-02 (DIA DE TODOS LOS SANTOS), 2020-11-16 (INDEPENDENCIA DE CARTAGENA), 2020-12-08 (DIA DE LA INMACULADA CONCEPCION), 2020-12-24 (NAVIDAD), 2021-01-01 (AÑO NUEVO), 2021-01-11 (DIA DE LOS SANTOS REYES MAGOS).

## Resources

| Resource | Group | Rate |
| --- | --- | --- |
| PM | EQUIPO | 81317.5 |
| Director de Arquitectura Empresarial | EQUIPO | 65014.5 |
| Arquitecto en sistemas | EQUIPO | 60987.5 |
| Especialista en Telemática e Infraestructura | EQUIPO | 63427 |
| Líder de Tecnología | EQUIPO | 63486.5 |
| Especialista BigData | EQUIPO | 60987.5 |
| Ingeniero de Requerimientos | EQUIPO | 56108.5 |
| Técnico de Soporte y Pruebas 1 | TECN SP | 36592.5 |
| Técnico de Soporte y Pruebas 2 | TECN SP | 36592.5 |
| Técnico de Soporte y Pruebas 3 | TECN SP | 36592.5 |
| Ingeniero Electrónico | EQUIPO | 60987.5 |
| Técnico Electronico 1 | TEC ELEC | 36592.5 |
| Técnico Electronico 2 | TEC ELEC | 36592.5 |
| Técnico Electronico 3 | TEC ELEC | 36592.5 |
| Técnico CDEG 1 | TEC CDEG | 41997.5 |
| Técnico CDEG 2 | TEC CDEG | 41997.5 |
| Técnico CDEG 3 | TEC CDEG | 41997.5 |
| Técnico CDEG 4 | TEC CDEG | 41997.5 |
| Técnico CDEG 5 | TEC CDEG | 41997.5 |
| Técnico CDEG 6 | TEC CDEG | 41997.5 |
| Computador | HERRAM | 95200000 |
| Multifuncional | HERRAM | 4760000 |
| Aire Acondicionado |  | 4760000 |
| Plataforma Base |  | 1666000000 |
| App Movil |  | 35700000 |
| Papelería |  | 3966666 |
| Transporte |  | 142800 |
| Sistema de Sonido |  | 4760000 |
| Canal Dedicado 1GB |  | 14280000 |
| Control de Acceso Biométrico |  | 3570000 |
| Servicio de Internet |  | 1190000 |
| Servicio de Hosting |  | 14280000 |
| Servicio de Infraestructura CLOUD Google |  | 71400000 |
| Muebles |  | 5355000 |
| Sillas |  | 7140000 |
| Cableado Estructrurado |  | 11900000 |
| UPS - Switches |  | 9000000 |
| Fortigate |  | 1190000 |
| Video WALL |  | 23800000 |
| Teléfono |  | 3570000 |
| Celular |  | 396666 |
| Servicio de Mensajeria |  | 1071000 |
| Mantenimiento de Equipos Intalaciones e Inmobiliario |  | 2380000 |
| Personalización Plataforma |  | 238000000 |
| Capacitaciones |  | 45874500 |
| Contrato CDEG a Todo Costo |  | 89601643 |
| Servicios Públicos |  | 1785000 |
| Gastos Operativos |  | 1190000 |

## Schedule

| ID | WBS | Task | Type | Duration | Start | Finish | Predecessors | Complete | Baseline start | Baseline finish | Baseline duration | Resources | Work | Actual work | Cost | Baseline cost | Actual cost |
| --- | --- | --- | --- | --- | --- | --- | --- | --- | --- | --- | --- | --- | --- | --- | --- | --- | --- |
| 1 | 1 | **Proyecto Centro de Gestión y Monitoreo CDEG** |  | 150d | 2020-08-03 A | 2021-03-09 A |  | 100% | 2020-08-03 | 2021-03-09 | 150d |  | 7696h | 7696h | 4,255,249,300 | 4,264,988,851.5 | 4,255,249,300 |
| 2 | 1.1 | **Plan de dirección del Proyecto** |  | 12d | 2020-08-03 A | 2020-08-18 A |  | 100% | 2020-08-03 | 2020-08-18 | 12d |  | 280h | 280h | 1,962,831,000 | 1,962,375,535.93 | 1,962,831,000 |
| 3 | 1.1.1 | **Líneas Base y Planes subsidiarios** |  | 7d | 2020-08-03 A | 2020-08-11 A |  | 100% | 2020-08-03 | 2020-08-11 | 7d |  | 240h | 240h | 1,959,411,000 | 1,959,122,837.53 | 1,959,411,000 |
| 4 | 1.1.1.1 | Desarrollar línea base del Alcance |  | 3d | 2020-08-03 A | 2020-08-05 A |  | 100% | 2020-08-03 | 2020-08-05 | 3d | Cableado Estructrurado; Capacitaciones; Celular [5000%]; Computador; Fortigate; Gastos Operativos; Muebles; Multifuncional; Papelería; Plataforma Base; PM; Servicio de Infraestructura CLOUD Google; Servicio de Internet; Sillas; Técnico de Soporte y Pruebas 1; UPS - Switches | 48h | 48h | 1,947,000,000 | 1,946,829,318.81 | 1,947,000,000 |
| 5 | 1.1.1.2 | Desarrollar línea base del Cronograma |  | 4d | 2020-08-03 A | 2020-08-06 A |  | 100% | 2020-08-03 | 2020-08-06 | 4d | Director de Arquitectura Empresarial; Transporte [400%] | 32h | 32h | 2,650,000 | 2,651,662.72 | 2,650,000 |
| 6 | 1.1.1.3 | Desarrollar línea base de Costos |  | 4d | 2020-08-03 A | 2020-08-06 A |  | 100% | 2020-08-03 | 2020-08-06 | 4d | Líder de Tecnología | 32h | 32h | 2,050,000 | 2,031,568 | 2,050,000 |
| 7 | 1.1.1.4 | Desarrollar Matriz RACI |  | 2d | 2020-08-03 A | 2020-08-04 A |  | 100% | 2020-08-03 | 2020-08-04 | 2d | Arquitecto en sistemas | 16h | 16h | 1,100,000 | 975,800 | 1,100,000 |
| 8 | 1.1.1.5 | Desarrollar Matriz de Riesgos |  | 4d | 2020-08-03 A | 2020-08-06 A |  | 100% | 2020-08-03 | 2020-08-06 | 4d | Especialista BigData; Especialista en Telemática e Infraestructura | 64h | 64h | 3,945,000 | 3,981,264 | 3,945,000 |
| 9 | 1.1.1.6 | Establecer Plan de aprobación de Entregables |  | 3d | 2020-08-07 A | 2020-08-11 A | 4, 5, 6, 7 | 100% | 2020-08-07 | 2020-08-11 | 3d | Ingeniero de Requerimientos; Técnico de Soporte y Pruebas 1; Transporte [300%] | 48h | 48h | 2,666,000 | 2,653,224 | 2,666,000 |
| 10 | 1.1.2 | **Registro de control integrado de cambios** |  | 12d | 2020-08-03 A | 2020-08-18 A |  | 100% | 2020-08-03 | 2020-08-18 | 12d |  | 40h | 40h | 3,420,000 | 3,252,698.4 | 3,420,000 |
| 11 | 1.1.2.1 | Definir el Plan de Gestión Integrada de cambios |  | 3d | 2020-08-12 A | 2020-08-14 A | 9 | 100% | 2020-08-12 | 2020-08-14 | 3d | PM | 24h | 24h | 2,020,000 | 1,951,619.04 | 2,020,000 |
| 12 | 1.1.2.2 | Desarrollar mecanismos de Gestión integrada de cambios |  | 2d | 2020-08-17 A | 2020-08-18 A | 11 | 100% | 2020-08-17 | 2020-08-18 | 2d | PM | 16h | 16h | 1,400,000 | 1,301,079.36 | 1,400,000 |
| 13 | 1.1.2.3 | Hito Aprobación Plan de Dirección del Proyecto | milestone | 0d | 2020-08-03 A | 2020-08-03 A |  | 100% | 2020-08-03 | 2020-08-03 | 0d | PM |  |  |  |  |  |
| 14 | 1.2 | **Diseño de la Plataforma Tecnológica Base para el Centro de Gestión** |  | 40d | 2020-08-07 A | 2020-10-01 A |  | 100% | 2020-08-07 | 2020-10-01 | 40d |  | 1456h | 1456h | 256,157,000 | 255,574,845.82 | 256,157,000 |
| 15 | 1.2.1 | **Diseño de la Arquitectura Base** |  | 24d | 2020-08-12 A | 2020-09-14 A |  | 100% | 2020-08-12 | 2020-09-14 | 24d |  | 448h | 448h | 111,180,800 | 111,250,821.15 | 111,180,800 |
| 16 | 1.2.1.1 | Geneñar diseño y documentación de la Arquitectura Base |  | 16d | 2020-08-12 A | 2020-09-02 A | 9 | 100% | 2020-08-12 | 2020-09-02 | 16d | Arquitecto en sistemas; Director de Arquitectura Empresarial; Técnico de Soporte y Pruebas 1; Transporte [1600%] | 384h | 384h | 23,150,000 | 23,096,890.88 | 23,150,000 |
| 17 | 1.2.1.2 | Determinar Infraestructura para la Arquitectura Base |  | 4d | 2020-09-03 A | 2020-09-08 A | 16 | 100% | 2020-09-03 | 2020-09-08 | 4d | Arquitecto en sistemas; Fortigate; Gastos Operativos; Mantenimiento de Equipos Intalaciones e Inmobiliario; Papelería; Servicio de Infraestructura CLOUD Google; Servicio de Internet; Servicio de Mensajeria; Servicios Públicos | 32h | 32h | 86,000,000 | 86,124,266.27 | 86,000,000 |
| 18 | 1.2.1.3 | Aprovisionar Infraestructura para la Arquitectura Base |  | 4d | 2020-09-09 A | 2020-09-14 A | 17 | 100% | 2020-09-09 | 2020-09-14 | 4d | Especialista en Telemática e Infraestructura | 32h | 32h | 2,030,800 | 2,029,664 | 2,030,800 |
| 19 | 1.2.2 | **Diccionario de las Variables de Integración** |  | 24d | 2020-08-07 A | 2020-09-09 A |  | 100% | 2020-08-07 | 2020-09-09 | 24d |  | 192h | 192h | 12,105,000 | 12,009,480 | 12,105,000 |
| 20 | 1.2.2.1 | Establecer las variables que se almacenarán en la Plataforma Tecnológica |  | 15d | 2020-08-07 A | 2020-08-27 A | 4 | 100% | 2020-08-07 | 2020-08-27 | 15d | Líder de Tecnología | 120h | 120h | 7,620,000 | 7,618,380 | 7,620,000 |
| 21 | 1.2.2.2 | Generar diccionario de Datos y Diagramas |  | 2d | 2020-09-02 A | 2020-09-03 A | 7, 20 | 100% | 2020-09-02 | 2020-09-03 | 2d | Especialista BigData | 16h | 16h | 1,050,000 | 975,800 | 1,050,000 |
| 22 | 1.2.2.3 | Implementar Bases de Datos en la Arquitectura |  | 4d | 2020-09-04 A | 2020-09-09 A | 21 | 100% | 2020-09-04 | 2020-09-09 | 4d | Especialista BigData | 32h | 32h | 2,035,000 | 1,951,600 | 2,035,000 |
| 23 | 1.2.2.4 | Generar Archivos JSON con las tramas de datos |  | 3d | 2020-08-28 A | 2020-09-01 A | 20 | 100% | 2020-08-28 | 2020-09-01 | 3d | Especialista BigData | 24h | 24h | 1,400,000 | 1,463,700 | 1,400,000 |
| 24 | 1.2.3 | **Documentación técnica de comunicación entre el CDEG y los STS** |  | 21d | 2020-09-03 A | 2020-10-01 A |  | 100% | 2020-09-03 | 2020-10-01 | 21d |  | 816h | 816h | 132,871,200 | 132,314,544.67 | 132,871,200 |
| 25 | 1.2.3.1 | Establecer protocolos de comunicación CDEG y STS |  | 15d | 2020-09-03 A | 2020-09-23 A | 4, 7, 16 | 100% | 2020-09-03 | 2020-09-23 | 15d | Director de Arquitectura Empresarial; Líder de Tecnología; PM; Técnico de Soporte y Pruebas 1; Transporte [1500%] | 480h | 480h | 31,700,250 | 31,711,310.4 | 31,700,250 |
| 26 | 1.2.3.2 | Establecer esquema y canal de comunicación entre CDEG y STS |  | 15d | 2020-09-03 A | 2020-09-23 A | 4, 7, 16 | 100% | 2020-09-03 | 2020-09-23 | 15d | Ingeniero de Requerimientos; Técnico de Soporte y Pruebas 2 | 240h | 240h | 11,150,650 | 11,124,120 | 11,150,650 |
| 27 | 1.2.3.3 | Establecer Esquema de seguridad de comunicaciones |  | 6d | 2020-09-24 A | 2020-10-01 A | 25, 26 | 100% | 2020-09-24 | 2020-10-01 | 6d | Fortigate; Gastos Operativos; Ingeniero de Requerimientos; Mantenimiento de Equipos Intalaciones e Inmobiliario; Papelería; Servicio de Infraestructura CLOUD Google; Servicio de Internet; Servicio de Mensajeria; Servicios Públicos; Técnico de Soporte y Pruebas 2; Transporte [600%] | 96h | 96h | 90,020,300 | 89,479,114.27 | 90,020,300 |
| 28 | 1.2.3.4 | Hito Aprobación de Diseño de la Plataforma Base | milestone | 0d | 2020-10-01 A | 2020-10-01 A | 27 | 100% | 2020-10-01 | 2020-10-01 | 0d | PM |  |  |  |  |  |

| ID | WBS | Task | Type | Duration | Start | Finish | Predecessors | Complete | Baseline start | Baseline finish | Baseline duration | Resources | Work | Actual work | Cost | Baseline cost | Actual cost |
| --- | --- | --- | --- | --- | --- | --- | --- | --- | --- | --- | --- | --- | --- | --- | --- | --- | --- |
| 29 | 1.3 | **Registro de acompañamientos a Transmilenio S.A. y consecionarios** |  | 71d | 2020-08-03 A | 2020-11-11 A |  | 100% | 2020-08-03 | 2020-11-11 | 71d |  | 992h | 992h | 169,325,350 | 169,358,647.29 | 169,325,350 |
| 30 | 1.3.1 | **Actas de las visitas a Transmilenio S.A. y a los operadores de flota (Mesas Técnicas)** |  | 18d | 2020-10-02 A | 2020-10-28 A |  | 100% | 2020-10-02 | 2020-10-28 | 18d |  | 384h | 384h | 43,730,350 | 43,735,748.7 | 43,730,350 |
| 31 | 1.3.1.1 | Asistir a las sesiones de los Operadores de Flota de TranMilenio S.A. |  | 15d | 2020-10-02 A | 2020-10-23 A | 4, 5, 20, 27 | 100% | 2020-10-02 | 2020-10-23 | 15d | Celular [5000%]; Ingeniero de Requerimientos; PM; Técnico de Soporte y Pruebas 3; Transporte [1500%] | 360h | 360h | 42,850,000 | 42,857,528.7 | 42,850,000 |
| 32 | 1.3.1.2 | Elaborar las Actas de visitas a TransMilenio S.A. y a los operadores de Flota |  | 3d | 2020-10-26 A | 2020-10-28 A | 31 | 100% | 2020-10-26 | 2020-10-28 | 3d | Técnico de Soporte y Pruebas 1 | 24h | 24h | 880,350 | 878,220 | 880,350 |
| 33 | 1.3.2 | **Archivo de recomendaciones a TransMilenio S.A. para la integración** |  | 71d | 2020-08-03 A | 2020-11-11 A |  | 100% | 2020-08-03 | 2020-11-11 | 71d |  | 608h | 608h | 125,595,000 | 125,622,898.59 | 125,595,000 |
| 34 | 1.3.2.1 | Elaborar y sustentar la documentación de recomendaciones técnicas y de mejora que se pueden implementar para optimizar la comunicación, transmisión, autenticación y demás aspectos de la solución |  | 6d | 2020-10-26 A | 2020-11-03 A | 16, 20, 27, 31 | 100% | 2020-10-26 | 2020-11-03 | 6d | Arquitecto en sistemas; Director de Arquitectura Empresarial; Especialista BigData; Especialista en Telemática e Infraestructura; Líder de Tecnología; PM; Transporte [600%] | 288h | 288h | 19,815,000 | 19,827,380.16 | 19,815,000 |
| 35 | 1.3.2.2 | Analizar respuesta del ente gestor con respecto a la documentación de recomendaciones y optimización |  | 2d | 2020-11-04 A | 2020-11-05 A | 34 | 100% | 2020-11-04 | 2020-11-05 | 2d | Arquitecto en sistemas; Director de Arquitectura Empresarial; Especialista BigData; Especialista en Telemática e Infraestructura; Fortigate; Gastos Operativos; Líder de Tecnología; Mantenimiento de Equipos Intalaciones e Inmobiliario; Papelería; PM; Servicio de Infraestructura CLOUD Google; Servicio de Internet; Servicio de Mensajeria; Servicios Públicos; Transporte [200%] | 96h | 96h | 90,780,000 | 90,781,792.99 | 90,780,000 |
| 36 | 1.3.2.3 | Determinar el impacto de las recomendaciones y optimización |  | 4d | 2020-11-06 A | 2020-11-11 A | 4, 5, 6, 8, 35 | 100% | 2020-11-06 | 2020-11-11 | 4d | Arquitecto en sistemas; Director de Arquitectura Empresarial; Especialista BigData; Especialista en Telemática e Infraestructura; Ingeniero de Requerimientos; Líder de Tecnología; PM; Transporte [400%] | 224h | 224h | 15,000,000 | 15,013,725.44 | 15,000,000 |
| 37 | 1.3.2.4 | Hito Radicación de Actas de Acompañamientos y Recomendaciones | milestone | 0d | 2020-08-03 A | 2020-08-03 A |  | 100% | 2020-08-03 | 2020-08-03 | 0d | PM |  |  |  |  |  |
| 38 | 1.4 | **Diseño del espacio físico del CDEG en Fase I** |  | 94d | 2020-08-03 A | 2020-12-16 A |  | 100% | 2020-08-03 | 2020-12-16 | 94d |  | 1552h | 1552h | 155,070,000 | 155,391,786.27 | 155,070,000 |
| 39 | 1.4.1 | **Diseño de la planta física del Centro de Monitoreo y Gestión** |  | 69d | 2020-08-07 A | 2020-11-13 A |  | 100% | 2020-08-07 | 2020-11-13 | 69d |  | 816h | 816h | 39,070,000 | 39,057,399.36 | 39,070,000 |
| 40 | 1.4.1.1 | Realizar Planos del diseño físico del Centro de Monitoreo y Gestión dos propuestas |  | 20d | 2020-08-07 A | 2020-09-03 A | 4, 5, 6, 8 | 100% | 2020-08-07 | 2020-09-03 | 20d | Especialista en Telemática e Infraestructura; Ingeniero Electrónico; Técnico Electronico 1; Técnico Electronico 2; Técnico Electronico 3 | 800h | 800h | 37,470,000 | 37,470,720 | 37,470,000 |
| 41 | 1.4.1.2 | Definir sesión para sustentación y aprobación de la propuesta |  | 2d | 2020-11-12 A | 2020-11-13 A | 36, 40 | 100% | 2020-11-12 | 2020-11-13 | 2d | PM; Transporte [200%] | 16h | 16h | 1,600,000 | 1,586,679.36 | 1,600,000 |
| 42 | 1.4.2 | **Procedimientos de operación del CDEG** |  | 94d | 2020-08-03 A | 2020-12-16 A |  | 100% | 2020-08-03 | 2020-12-16 | 94d |  | 736h | 736h | 116,000,000 | 116,334,386.91 | 116,000,000 |
| 43 | 1.4.2.1 | Escribir los procedimientos de operación del CDEG |  | 29d | 2020-10-29 A | 2020-12-11 A | 4, 5, 6, 7, 8, 32 | 100% | 2020-10-29 | 2020-12-11 | 29d | Director de Arquitectura Empresarial; Técnico de Soporte y Pruebas 1; Técnico de Soporte y Pruebas 2; Técnico de Soporte y Pruebas 3 | 640h | 640h | 28,000,000 | 27,966,713.6 | 28,000,000 |
| 44 | 1.4.2.2 | Articular los procedimientos del CDEG con el sistema de gestión de calidad de Transmilenio S.A. |  | 3d | 2020-12-14 A | 2020-12-16 A | 43 | 100% | 2020-12-14 | 2020-12-16 | 3d | Director de Arquitectura Empresarial; Fortigate; Gastos Operativos; Mantenimiento de Equipos Intalaciones e Inmobiliario; Papelería; Servicio de Infraestructura CLOUD Google; Servicio de Internet; Servicio de Mensajeria; Servicios Públicos; Técnico de Soporte y Pruebas 1; Técnico de Soporte y Pruebas 2; Técnico de Soporte y Pruebas 3 | 96h | 96h | 88,000,000 | 88,367,673.31 | 88,000,000 |
| 45 | 1.4.2.3 | Hito Aprobación del diseño del CDEG | milestone | 0d | 2020-08-03 A | 2020-08-03 A |  | 100% | 2020-08-03 | 2020-08-03 | 0d | Director de Arquitectura Empresarial |  |  |  |  |  |
| 46 | 1.5 | **Diseño de Alistamiento del Centro de Gestión** |  | 115d | 2020-08-03 A | 2021-01-19 A |  | 100% | 2020-08-03 | 2021-01-19 | 115d |  | 1456h | 1456h | 835,065,950 | 836,457,891.29 | 835,065,950 |
| 47 | 1.5.1 | **Casos de uso con los requerimientos funcionales y no funcionales de la plataforma** |  | 25d | 2020-11-17 A | 2020-12-22 A |  | 100% | 2020-11-17 | 2020-12-22 | 25d |  | 384h | 384h | 28,765,000 | 28,612,169.6 | 28,765,000 |
| 48 | 1.5.1.1 | Realizar reuniones con las áreas funcionales de Transmilenio S.A. para determinar sus requerimientos |  | 20d | 2020-11-17 A | 2020-12-15 A | 9, 21, 23, 41 | 100% | 2020-11-17 | 2020-12-15 | 20d | Ingeniero de Requerimientos; PM; Transporte [2000%] | 320h | 320h | 25,000,000 | 24,844,153.6 | 25,000,000 |
| 49 | 1.5.1.2 | Documentar los requerimientos y aprobarlos por cada área funcional |  | 5d | 2020-12-16 A | 2020-12-22 A | 48 | 100% | 2020-12-16 | 2020-12-22 | 5d | Ingeniero de Requerimientos | 40h | 40h | 2,250,000 | 2,244,340 | 2,250,000 |
| 50 | 1.5.1.3 | Establecer la metodología de desarrollo y despliegue de nuevas funciones del CDEG |  | 3d | 2020-12-16 A | 2020-12-18 A | 48 | 100% | 2020-12-16 | 2020-12-18 | 3d | Líder de Tecnología | 24h | 24h | 1,515,000 | 1,523,676 | 1,515,000 |
| 51 | 1.5.2 | **Registro de servicios de integración con fuentes de datos externas** |  | 18d | 2020-12-21 A | 2021-01-18 A |  | 100% | 2020-12-21 | 2021-01-18 | 18d |  | 200h | 200h | 317,500,950 | 314,617,436 | 317,500,950 |
| 52 | 1.5.2.1 | Solicitar a la entidad los diccionarios, autenticación y diccionarios de servicios a integrar con CDEG |  | 2d | 2020-12-21 A | 2020-12-22 A | 48, 50 | 100% | 2020-12-21 | 2020-12-22 | 2d | Líder de Tecnología | 16h | 16h | 1,000,950 | 1,015,784 | 1,000,950 |
| 53 | 1.5.2.2 | Implementar servicios y colas de mensajería para consumir la información de los servicios |  | 5d | 2020-12-23 A | 2020-12-30 A | 52 | 100% | 2020-12-23 | 2020-12-30 | 5d | Arquitecto en sistemas | 40h | 40h | 2,500,000 | 2,439,500 | 2,500,000 |
| 54 | 1.5.2.3 | Integrar los servicios externos en el Front del CDEG |  | 7d | 2020-12-31 A | 2021-01-18 A | 53 | 100% | 2020-12-31 | 2021-01-18 | 7d | App Movil; Arquitecto en sistemas; Canal Dedicado 1GB; Especialista BigData; Líder de Tecnología; Personalización Plataforma; Servicio de Hosting | 144h | 144h | 314,000,000 | 311,162,152 | 314,000,000 |

| ID | WBS | Task | Type | Duration | Start | Finish | Predecessors | Complete | Baseline start | Baseline finish | Baseline duration | Resources | Work | Actual work | Cost | Baseline cost | Actual cost |
| --- | --- | --- | --- | --- | --- | --- | --- | --- | --- | --- | --- | --- | --- | --- | --- | --- | --- |
| 55 | 1.5.3 | **Diccionario de datos, modelos de datos de: bases de datos y data lake** |  | 18d | 2020-12-16 A | 2021-01-13 A |  | 100% | 2020-12-16 | 2021-01-13 | 18d |  | 184h | 184h | 13,750,000 | 13,656,440 | 13,750,000 |
| 56 | 1.5.3.1 | Generar diseño de las bases de datos con la implementación de los requerimientos |  | 6d | 2020-12-23 A | 2021-01-12 A | 49 | 100% | 2020-12-23 | 2021-01-12 | 6d | Especialista BigData | 48h | 48h | 2,900,000 | 2,927,400 | 2,900,000 |
| 57 | 1.5.3.2 | Generar diseño de las bases de datos del data lake |  | 2d | 2021-01-12 A | 2021-01-13 A | 49, 52 | 100% | 2021-01-12 | 2021-01-13 | 2d | Arquitecto en sistemas | 16h | 16h | 1,050,000 | 975,800 | 1,050,000 |
| 58 | 1.5.3.3 | Diseñar unidades de análisi, formulación y diseo de los modelos analíticos |  | 15d | 2020-12-16 A | 2021-01-07 A | 4, 5, 8, 48 | 100% | 2020-12-16 | 2021-01-07 | 15d | Especialista en Telemática e Infraestructura; Transporte [1500%] | 120h | 120h | 9,800,000 | 9,753,240 | 9,800,000 |
| 59 | 1.5.4 | **Ambiente de pruebas (QA) de la plataforma** |  | 115d | 2020-08-03 A | 2021-01-19 A |  | 100% | 2020-08-03 | 2021-01-19 | 115d |  | 688h | 688h | 475,050,000 | 479,571,845.69 | 475,050,000 |
| 60 | 1.5.4.1 | Desplegar la infraestructura Google Cloud para soportar CDEG |  | 5d | 2021-01-08 A | 2021-01-15 A | 18, 58 | 100% | 2021-01-08 | 2021-01-15 | 5d | Director de Arquitectura Empresarial; Especialista en Telemática e Infraestructura; Fortigate; Gastos Operativos; Líder de Tecnología; Mantenimiento de Equipos Intalaciones e Inmobiliario; Papelería; PM; Servicio de Internet; Servicio de Mensajeria; Servicios Públicos; Transporte [500%] | 160h | 160h | 24,000,000 | 24,416,483.07 | 24,000,000 |
| 61 | 1.5.4.2 | Implementar y desplegar las nuevas funcionalidades de la plataformaCDEG - QA |  | 2d | 2021-01-18 A | 2021-01-19 A | 60 | 100% | 2021-01-18 | 2021-01-19 | 2d | Arquitecto en sistemas | 16h | 16h | 1,050,000 | 975,800 | 1,050,000 |
| 62 | 1.5.4.3 | Construir e instalar el Centro de Monitoreo y Gestión |  | 16d | 2020-12-14 A | 2021-01-06 A | 41, 43 | 100% | 2020-12-14 | 2021-01-06 | 16d | Aire Acondicionado; App Movil; Canal Dedicado 1GB; Contrato CDEG a Todo Costo; Control de Acceso Biométrico; Ingeniero Electrónico; Personalización Plataforma; Servicio de Hosting; Sistema de Sonido; Técnico Electronico 1; Técnico Electronico 2; Técnico Electronico 3; Teléfono; Video WALL | 512h | 512h | 450,000,000 | 454,179,562.62 | 450,000,000 |
| 63 | 1.5.4.4 | Hito Implementación del CDEG ambuiente de pruebas | milestone | 0d | 2020-08-03 A | 2020-08-03 A |  | 100% | 2020-08-03 | 2020-08-03 | 0d | Ingeniero Electrónico; PM |  |  |  |  |  |
| 64 | 1.6 | **Informes de resultados de las pruebas y entrega de la Plataforma Tecnológica** |  | 141d | 2020-08-03 A | 2021-02-24 A |  | 100% | 2020-08-03 | 2021-02-24 | 141d |  | 1264h | 1264h | 699,700,000 | 699,567,952.51 | 699,700,000 |
| 65 | 1.6.1 | **Diseño y elaboración de los protocolos de prueba de la plataforma y sus componentes** |  | 3d | 2021-01-20 A | 2021-01-22 A |  | 100% | 2021-01-20 | 2021-01-22 | 3d |  | 240h | 240h | 13,800,000 | 13,894,954.08 | 13,800,000 |
| 66 | 1.6.1.1 | Diseñar los planes para las pruebas funcionales para las áreas de TransMilenio S.A. |  | 3d | 2021-01-20 A | 2021-01-22 A | 4, 5, 6, 8, 12, 22, 23, 27, 40, 43, 54, 61, 62 | 100% | 2021-01-20 | 2021-01-22 | 3d | Ingeniero de Requerimientos; Técnico de Soporte y Pruebas 1; Transporte [300%] | 48h | 48h | 2,700,000 | 2,653,224 | 2,700,000 |
| 67 | 1.6.1.2 | Diseñar las pruebas de carga del CDEG |  | 3d | 2021-01-20 A | 2021-01-22 A | 4, 5, 6, 8, 12, 22, 23, 27, 61, 62, 40, 43, 54 | 100% | 2021-01-20 | 2021-01-22 | 3d | Arquitecto en sistemas | 24h | 24h | 1,400,000 | 1,463,700 | 1,400,000 |
| 68 | 1.6.1.3 | Diseñar las pruebas de integración del CDEG y los STS |  | 3d | 2021-01-20 A | 2021-01-22 A | 4, 5, 6, 8, 12, 22, 23, 27, 61, 62, 40, 43, 54 | 100% | 2021-01-20 | 2021-01-22 | 3d | Especialista en Telemática e Infraestructura; Líder de Tecnología; Técnico de Soporte y Pruebas 2 | 72h | 72h | 3,900,000 | 3,924,144 | 3,900,000 |
| 69 | 1.6.1.4 | Diseñar las pruebas de las bases de datos del CDEG |  | 3d | 2021-01-20 A | 2021-01-22 A | 4, 5, 6, 8, 12, 22, 23, 27, 61, 62, 40, 43, 54 | 100% | 2021-01-20 | 2021-01-22 | 3d | Especialista BigData | 24h | 24h | 1,400,000 | 1,463,700 | 1,400,000 |
| 70 | 1.6.1.5 | Diseñar las pruebas de procedimientos |  | 3d | 2021-01-20 A | 2021-01-22 A | 4, 5, 6, 8, 12, 22, 23, 27, 61, 62, 40, 43, 54 | 100% | 2021-01-20 | 2021-01-22 | 3d | Director de Arquitectura Empresarial; PM; Técnico de Soporte y Pruebas 3 | 72h | 72h | 4,400,000 | 4,390,186.08 | 4,400,000 |
| 71 | 1.6.2 | **Informe de resultados de la ejecución de las pruebas** |  | 4d | 2021-01-25 A | 2021-01-28 A |  | 100% | 2021-01-25 | 2021-01-28 | 4d |  | 480h | 480h | 264,700,000 | 263,419,161.6 | 264,700,000 |
| 72 | 1.6.2.1 | Informar resultados de las pruebas funcionales para las áreas de TransMilenio S.A. |  | 4d | 2021-01-25 A | 2021-01-28 A | 66 | 100% | 2021-01-25 | 2021-01-28 | 4d | Ingeniero de Requerimientos; Personalización Plataforma; Técnico CDEG 1; Técnico CDEG 2; Técnico de Soporte y Pruebas 1; Transporte [400%] | 128h | 128h | 245,500,000 | 244,225,470.72 | 245,500,000 |
| 73 | 1.6.2.2 | Informar resultados de las pruebas de carga del CDEG |  | 4d | 2021-01-25 A | 2021-01-28 A | 67 | 100% | 2021-01-25 | 2021-01-28 | 4d | Arquitecto en sistemas | 32h | 32h | 1,900,000 | 1,951,600 | 1,900,000 |
| 74 | 1.6.2.3 | Informar resultados de las pruebas de integración del CDEG y los STS |  | 4d | 2021-01-25 A | 2021-01-28 A | 68 | 100% | 2021-01-25 | 2021-01-28 | 4d | Especialista en Telemática e Infraestructura; Líder de Tecnología; Técnico de Soporte y Pruebas 2 | 96h | 96h | 5,200,000 | 5,232,192 | 5,200,000 |
| 75 | 1.6.2.4 | Informar resultados de las pruebas de las bases de datos del CDEG |  | 4d | 2021-01-25 A | 2021-01-28 A | 69 | 100% | 2021-01-25 | 2021-01-28 | 4d | Especialista BigData; Técnico CDEG 3; Técnico CDEG 4 | 96h | 96h | 4,700,000 | 4,639,438.72 | 4,700,000 |
| 76 | 1.6.2.5 | Informar resultados de las pruebas de procedimientos |  | 4d | 2021-01-25 A | 2021-01-28 A | 70 | 100% | 2021-01-25 | 2021-01-28 | 4d | Director de Arquitectura Empresarial; PM; Técnico CDEG 5; Técnico CDEG 6 | 128h | 128h | 7,400,000 | 7,370,460.16 | 7,400,000 |
| 77 | 1.6.3 | **Ambiente de Producción de la plataforma** |  | 141d | 2020-08-03 A | 2021-02-24 A |  | 100% | 2020-08-03 | 2021-02-24 | 141d |  | 544h | 544h | 421,200,000 | 422,253,836.83 | 421,200,000 |
| 78 | 1.6.3.1 | Desplegar la infraestructura Google Cloud para soportar CDEG producción |  | 8d | 2021-01-29 A | 2021-02-09 A | 72, 73, 74, 75, 76 | 100% | 2021-01-29 | 2021-02-09 | 8d | App Movil; Arquitecto en sistemas; Canal Dedicado 1GB; Especialista en Telemática e Infraestructura; Fortigate; Gastos Operativos; Mantenimiento de Equipos Intalaciones e Inmobiliario; Papelería; Personalización Plataforma; PM; Servicio de Hosting; Servicio de Infraestructura CLOUD Google; Servicio de Internet; Servicio de Mensajeria; Servicios Públicos; Transporte [800%] | 192h | 192h | 399,000,000 | 400,741,911.71 | 399,000,000 |
| 79 | 1.6.3.2 | Implementar y desplegar las nuevas funcionalidades de la plataforma CDEG producción |  | 8d | 2021-02-10 A | 2021-02-19 A | 78 | 100% | 2021-02-10 | 2021-02-19 | 8d | Director de Arquitectura Empresarial; Ingeniero Electrónico; Líder de Tecnología; Transporte [800%] | 192h | 192h | 14,000,000 | 13,269,661.44 | 14,000,000 |
| 80 | 1.6.3.3 | Diseñar e implementar pruebas de Humo |  | 5d | 2021-01-29 A | 2021-02-04 A | 72 | 100% | 2021-01-29 | 2021-02-04 | 5d | Ingeniero de Requerimientos; Técnico de Soporte y Pruebas 1; Técnico de Soporte y Pruebas 2 | 120h | 120h | 5,100,000 | 5,171,740 | 5,100,000 |
| 81 | 1.6.3.4 | Entregar Usuario Administrador y cuentas de servicio (Google) a TransMilenio S.A. |  | 1d | 2021-02-22 A | 2021-02-22 A | 78, 79, 80 | 100% | 2021-02-22 | 2021-02-22 | 1d | PM; Transporte | 8h | 8h | 800,000 | 793,339.68 | 800,000 |
| 82 | 1.6.3.5 | Hacer transferencia de cuenta de servicio de facturación a TrnasMilenio S.A. |  | 2d | 2021-02-23 A | 2021-02-24 A | 81 | 100% | 2021-02-23 | 2021-02-24 | 2d | Arquitecto en sistemas; Líder de Tecnología; Transporte [200%] | 32h | 32h | 2,300,000 | 2,277,184 | 2,300,000 |
| 83 | 1.6.3.6 | Hito Construcción y Ejecución de Pruebas del CDEG y Despliegue del ambiente de producción | milestone | 0d | 2020-08-03 A | 2020-08-03 A |  | 100% | 2020-08-03 | 2020-08-03 | 0d | Arquitecto en sistemas; Líder de Tecnología; PM |  |  |  |  |  |

| ID | WBS | Task | Type | Duration | Start | Finish | Predecessors | Complete | Baseline start | Baseline finish | Baseline duration | Resources | Work | Actual work | Cost | Baseline cost | Actual cost |
| --- | --- | --- | --- | --- | --- | --- | --- | --- | --- | --- | --- | --- | --- | --- | --- | --- | --- |
| 84 | 1.7 | **Informe de transferencia del conocimiento** |  | 32d | 2021-01-25 A | 2021-03-09 A |  | 100% | 2021-01-25 | 2021-03-09 | 32d |  | 696h | 696h | 57,100,000 | 57,165,593.66 | 57,100,000 |
| 85 | 1.7.1 | **Plan de Transferencia de conocimiento** |  | 4d | 2021-02-25 A | 2021-03-02 A |  | 100% | 2021-02-25 | 2021-03-02 | 4d |  | 224h | 224h | 33,000,000 | 32,713,606.94 | 33,000,000 |
| 86 | 1.7.1.1 | Diseñar Plan de Transferencia de conocimiento |  | 2d | 2021-02-25 A | 2021-02-26 A | 7, 16, 21, 27, 41, 43, 81, 82 | 100% | 2021-02-25 | 2021-02-26 | 2d | Arquitecto en sistemas; Celular [5000%]; Director de Arquitectura Empresarial; Especialista BigData; Especialista en Telemática e Infraestructura; Ingeniero de Requerimientos; Ingeniero Electrónico; Líder de Tecnología; PM; Técnico de Soporte y Pruebas 1; Técnico de Soporte y Pruebas 2; Técnico de Soporte y Pruebas 3 | 176h | 176h | 30,000,000 | 29,786,816.22 | 30,000,000 |
| 87 | 1.7.1.2 | Programar sesiones de Transferencia de conocimiento |  | 2d | 2021-03-01 A | 2021-03-02 A | 86 | 100% | 2021-03-01 | 2021-03-02 | 2d | Director de Arquitectura Empresarial; PM; Técnico de Soporte y Pruebas 1 | 48h | 48h | 3,000,000 | 2,926,790.72 | 3,000,000 |
| 88 | 1.7.2 | **Manuales técnicos y de usuario final** |  | 31d | 2021-01-25 A | 2021-03-08 A |  | 100% | 2021-01-25 | 2021-03-08 | 31d |  | 288h | 288h | 13,400,000 | 13,661,200 | 13,400,000 |
| 89 | 1.7.2.1 | Generar Manual de Usuario Final del CDEG |  | 16d | 2021-01-25 A | 2021-02-15 A | 66 | 100% | 2021-01-25 | 2021-02-15 | 16d | Técnico de Soporte y Pruebas 3 | 128h | 128h | 4,500,000 | 4,683,840 | 4,500,000 |
| 90 | 1.7.2.2 | Generar Manuales Técnicos del CDEG |  | 20d | 2021-02-05 A | 2021-03-08 A | 67, 68, 69 | 100% | 2021-02-05 | 2021-03-08 | 20d | Ingeniero de Requerimientos | 160h | 160h | 8,900,000 | 8,977,360 | 8,900,000 |
| 91 | 1.7.3 | **Actas de sesiones de ejecución de jornadas de capacitación** |  | 5d | 2021-03-03 A | 2021-03-09 A |  | 100% | 2021-03-03 | 2021-03-09 | 5d |  | 184h | 184h | 10,700,000 | 10,790,786.72 | 10,700,000 |
| 92 | 1.7.3.1 | Programar las capacitaciones Técnicas, procedimental y de operación del CDEG |  | 2d | 2021-03-03 A | 2021-03-04 A | 86, 87 | 100% | 2021-03-03 | 2021-03-04 | 2d | Arquitecto en sistemas; Director de Arquitectura Empresarial; Especialista BigData; Especialista en Telemática e Infraestructura; Ingeniero Electrónico; Líder de Tecnología; PM; Transporte [300%] | 112h | 112h | 7,700,000 | 7,727,726.72 | 7,700,000 |
| 93 | 1.7.3.2 | Elaborar las Actas de las capacitaciones Técnicas, procedimental y de operación del CDEG |  | 3d | 2021-03-05 A | 2021-03-09 A | 92 | 100% | 2021-03-05 | 2021-03-09 | 3d | Técnico de Soporte y Pruebas 1; Técnico de Soporte y Pruebas 2; Técnico de Soporte y Pruebas 3; Transporte [300%] | 72h | 72h | 3,000,000 | 3,063,060 | 3,000,000 |
| 94 | 1.7.3.3 | Hito Entrega de la solución con documentación y transferencia de conocimientos | milestone | 0d | 2021-03-09 A | 2021-03-09 A | 44, 56, 57, 89, 90, 93 | 100% | 2021-03-09 | 2021-03-09 | 0d | PM |  |  |  |  |  |
| 95 | 1.8 | Gestión de Contingencia |  | 6d | 2020-08-03 A | 2020-08-10 A |  | 100% | 2020-08-03 | 2020-08-10 | 6d |  |  |  | 120,000,000 | 129,096,598.73 | 120,000,000 |
